# Projekt Badsanierung

Schedule from MS Project, 2013-03-04 to 2013-03-08, costs in €.
Microsoft

## Calendars

- Standard: Mon-Fri 08:00-12:00, 13:00-17:00; Sat-Sun off.

## Resources

| Resource | Rate |
| --- | --- |
| Auszubildende | 10 |
| Monteur | 40 |
| Firmenwagen | 25 |

## Schedule

| ID | Task | Duration | Start | Finish | Predecessors | Total slack | Resources | Work | Cost |
| --- | --- | --- | --- | --- | --- | --- | --- | --- | --- |
| 1 | Firmenwagen mit Materialien beladen | 30min | 2013-03-04 08:00 | 2013-03-04 08:30 |  | 0d | Auszubildende; Monteur | 1h | 25 |
| 2 | Anfahrt | 30min | 2013-03-04 08:30 | 2013-03-04 09:00 | 1 | 0d | Auszubildende; Firmenwagen; Monteur | 1.5h | 37.5 |
| 3 | Material und Werkzeug entladen | 15min | 2013-03-04 09:00 | 2013-03-04 09:15 | 2 | 0.03d | Auszubildende | 0.25h | 2.5 |
| 4 | Ort für die neuen Objekte festlegen | 30min | 2013-03-04 09:00 | 2013-03-04 09:30 | 2 | 0d | Monteur | 0.5h | 20 |
| 5 | Demontage Sanitärobjekte | 45min | 2013-03-04 09:30 | 2013-03-04 10:15 | 3, 4 | 0.03d | Auszubildende | 0.75h | 7.5 |
| 6 | Demontage Heizung und Abwasserfallstrang | 1h | 2013-03-04 09:30 | 2013-03-04 10:30 | 3, 4 | 0d | Monteur | 1h | 40 |
| 7 | Demontage Badewanne | 30min | 2013-03-04 10:30 | 2013-03-04 11:00 | 5, 6 | 0d | Auszubildende; Monteur | 1h | 25 |
| 8 | Schutt entsorgen | 1h | 2013-03-04 11:00 | 2013-03-04 12:00 | 7 | 0d | Auszubildende; Monteur | 2h | 50 |
| 9 | Montage Abwasserfallrohr | 2h | 2013-03-04 13:00 | 2013-03-04 15:00 | 8 | 0d | Auszubildende; Monteur | 4h | 100 |
| 10 | Montage Steigestrang | 2h | 2013-03-04 15:00 | 2013-03-04 17:00 | 9 | 0d | Auszubildende; Monteur | 4h | 100 |
| 11 | Schlitzarbeiten | 45min | 2013-03-05 08:00 | 2013-03-05 08:45 | 10 | 0d | Auszubildende | 0.75h | 7.5 |
| 12 | Wasser- und Abwasseranschluß verlegen | 4h | 2013-03-05 08:45 | 2013-03-05 13:45 | 11 | 0d | Auszubildende; Monteur | 8h | 200 |
| 13 | Leitungen befestigen und Schlitze verschließen | 1.5h | 2013-03-05 13:45 | 2013-03-05 15:15 | 12 | 0d | Auszubildende | 1.5h | 15 |
| 14 | Wände begradigen und Fliesen legen | 1d | 2013-03-05 15:15 | 2013-03-06 15:15 | 13 | 0d | Monteur | 8h | 320 |
| 15 | Sanitärobjekte montieren | 4h | 2013-03-07 15:15 | 2013-03-08 10:15 | 14FS+1ed | 0d | Auszubildende | 4h | 40 |
| 16 | Heizung montieren | 3h | 2013-03-07 15:15 | 2013-03-08 09:15 | 14FS+1ed | 0.12d | Monteur | 3h | 120 |
| 17 | Badewanne montieren | 2h | 2013-03-08 10:15 | 2013-03-08 13:15 | 15, 16 | 0d | Auszubildende; Monteur | 4h | 100 |
| 18 | Bauabnahme | 30min | 2013-03-08 13:15 | 2013-03-08 13:45 | 17 | 0d | Monteur | 0.5h | 20 |
